# GD-01 - met prefab spouwblad

Schedule from MS Project, 2003-01-12 to 2003-01-25, status date 2003-01-08.
BAM Nelissen Van Egteren

## Calendars

- ALLEEN WERKDAGEN: Mon-Fri 08:30-12:30, 13:00-17:00; Sat-Sun off. Exceptions (off unless hours are given): 2003-01-11 to 2003-01-12 08:30-12:30, 13:00-17:00, 2003-01-18 to 2003-01-19 08:30-12:30, 13:00-17:00, 2003-01-25 to 2003-01-26 08:30-12:30, 13:00-17:00.

## Schedule

| ID | WBS | Task | Type | Duration | Start | Finish | Predecessors | Total slack |
| --- | --- | --- | --- | --- | --- | --- | --- | --- |
| 1 | 1 | **GEVEL/DAK FASE** |  | 14d | 2003-01-12 | 2003-01-25 |  | 0d |
| 2 | 1.1 | prefab spouwblad+ kozijn |  | 2d | 2003-01-12 | 2003-01-13 |  | 0d |
| 3 | 1.2 | veiligheidssteiger aanbrengen |  | 1d | 2003-01-14 | 2003-01-14 | 2SS+2d | 0d |
| 4 | 1.3 | muurplaat+gootbeugels aanbrengen |  | 3d | 2003-01-15 | 2003-01-17 | 3SS+1d | 0d |
| 5 | 1.4 | gordingen+ravelingen monteren |  | 3d | 2003-01-16 | 2003-01-18 | 4SS+1d | 0d |
| 6 | 1.5 | isolatie dakplaten aanbrengen |  | 3d | 2003-01-18 | 2003-01-20 | 5SS+2d | 0d |
| 7 | 1.6 | panlatten+dakrandvoorziening |  | 2d | 2003-01-20 | 2003-01-21 | 6SS+2d | 0d |
| 8 | 1.7 | dakpannen leggen |  | 2d | 2003-01-22 | 2003-01-23 | 7SS+2d | 0d |
| 9 | 1.8 | dakramen+dakdoorvoeren |  | 2d | 2003-01-24 | 2003-01-25 | 8SS+2d | 0d |
| 10 | 1.9 | start afbouw fase | milestone | 0d | 2003-01-25 | 2003-01-25 | 9SS+2d | 0d |
